# Name Access Control Module Project Schedule

Schedule from MS Project, 2007-01-09 to 2007-04-22, 4 hours a day.
Venaca

## Calendars

- Standard: Mon off; Tue 16:00-20:00; Wed off; Thu 16:00-20:00; Fri off; Sat-Sun 13:00-17:00. Exceptions (off unless hours are given): 2007-04-02 08:00-12:00, 13:00-17:00.

## Resources

| Resource |
| --- |
| Matthew |
| Ben |
| Anthony |
| Dean |
| Rob |

## Schedule

| ID | WBS | Task | Duration | Start | Finish | Predecessors | Baseline start | Baseline finish | Baseline duration | Total slack | Free slack | Resources | Work |
| --- | --- | --- | --- | --- | --- | --- | --- | --- | --- | --- | --- | --- | --- |
| 1 | 1 | **Pre-Release** | 1d | 2007-01-09 16:00 | 2007-01-09 20:00 |  |  |  |  | 29.5d | 0d | Ben; Matthew; Rob | 28h |
| 2 | 1.1 | **SRS Document** | 1d | 2007-01-09 16:00 | 2007-01-09 20:00 |  |  |  |  | 29.5d |  | Ben; Matthew; Rob | 16h |
| 3 | 1.1.1 | Acceptance Testing Creation | 4h | 2007-01-09 16:00 | 2007-01-09 20:00 |  |  |  |  | 21.5d |  | Ben | 4h |
| 4 | 2 | **Release 1** | 10.5d | 2007-01-11 16:00 | 2007-01-28 15:00 | 1 | 2007-01-09 16:00 | 2007-01-25 18:00 | 9.5d | 29.5d | 0d | Anthony; Ben; Dean; Matthew; Rob | 486h |
| 5 | 2.1 | **Java Refreasher** | 1.5d | 2007-01-11 16:00 | 2007-01-13 15:00 |  |  |  |  | 35d |  |  | 8h |
| 6 | 2.1.1 | Java refresher for Matthew | 2h | 2007-01-11 16:00 | 2007-01-11 18:00 |  | 2007-01-09 16:00 | 2007-01-09 18:00 | 2h | 27d | 0d | Matthew | 2h |
| 7 | 2.1.2 | Java refresher for Ben | 6h | 2007-01-11 16:00 | 2007-01-13 15:00 |  | 2007-01-09 16:00 | 2007-01-11 18:00 | 6h | 28.25d | 0d | Ben | 6h |
| 8 | 2.2 | **Database** | 8d | 2007-01-11 16:00 | 2007-01-23 20:00 |  | 2007-01-09 16:00 | 2007-01-18 18:00 | 5.5d | 31d |  | Anthony | 64h |
| 9 | 2.2.1 | Setup server machine | 3h | 2007-01-11 16:00 | 2007-01-11 19:00 |  | 2007-01-09 16:00 | 2007-01-09 19:00 | 3h | 23d | 0d | Anthony | 3h |
| 10 | 2.2.2 | Install mySql on server machine | 3h | 2007-01-11 19:00 | 2007-01-13 15:00 | 9 | 2007-01-09 19:00 | 2007-01-11 18:00 | 3h | 23d | 0d | Anthony | 3h |
| 11 | 2.2.3 | Define the database schema | 14h | 2007-01-13 15:00 | 2007-01-18 20:00 | 10 | 2007-01-11 18:00 | 2007-01-13 15:00 | 4h | 23d | 0d | Anthony | 14h |
| 12 | 2.2.4 | Create the database creation script | 12h | 2007-01-20 13:00 | 2007-01-23 20:00 | 11 | 2007-01-13 15:00 | 2007-01-18 18:00 | 12h | 24d |  | Anthony | 12h |
| 13 | 2.3 | **Data Access Object** | 9d | 2007-01-11 16:00 | 2007-01-25 20:00 |  | 2007-01-09 16:00 | 2007-01-23 18:00 | 8.5d | 29.5d |  | Dean | 62h |
| 14 | 2.3.1 | Hibernate learning curve | 3h | 2007-01-11 16:00 | 2007-01-11 19:00 |  | 2007-01-09 16:00 | 2007-01-09 19:00 | 3h | 21.5d | 0d | Dean | 3h |
| 15 | 2.3.2 | Install Hibernate | 3h | 2007-01-11 19:00 | 2007-01-13 15:00 | 14 | 2007-01-09 19:00 | 2007-01-11 18:00 | 3h | 21.5d | 0d | Dean | 3h |
| 16 | 2.3.3 | Setup domain model | 4h | 2007-01-13 15:00 | 2007-01-14 15:00 | 15 | 2007-01-13 15:00 | 2007-01-14 15:00 | 4h | 21.5d | 0d | Dean | 4h |
| 17 | 2.3.4 | Define xml mappings for Hibernate | 8h | 2007-01-20 13:00 | 2007-01-21 17:00 | 16, 11 | 2007-01-14 15:00 | 2007-01-20 15:00 | 12h | 23d | 0d | Dean | 8h |
| 18 | 2.3.5 | Define interface to database through Hibernate | 8h | 2007-01-23 16:00 | 2007-01-25 20:00 | 17 | 2007-01-20 15:00 | 2007-01-23 18:00 | 8h | 23d |  | Dean | 8h |
| 19 | 2.4 | **Import MARC Records** | 5.25d | 2007-01-11 18:00 | 2007-01-20 16:00 |  | 2007-01-09 16:00 | 2007-01-20 16:00 | 6.75d | 34.25d |  | Matthew | 39h |
| 20 | 2.4.1 | XML Jave learning curve | 4h | 2007-01-11 18:00 | 2007-01-13 15:00 | 6 | 2007-01-09 18:00 | 2007-01-11 18:00 | 4h | 27d | 0d | Matthew | 4h |
| 21 | 2.4.2 | Define mapping of MARC bib xml to domain objects | 1h | 2007-01-13 15:00 | 2007-01-13 16:00 | 20 | 2007-01-11 18:00 | 2007-01-11 19:00 | 1h | 27d | 0.75d | Matthew | 1h |
| 22 | 2.4.3 | Create MARC bib record parser | 4h | 2007-01-14 15:00 | 2007-01-16 18:00 | 21, 16 | 2007-01-14 15:00 | 2007-01-16 18:00 | 4h | 26.25d | 0d | Matthew | 4h |
| 23 | 2.4.4 | Define mapping of MARC auth xml to domain objects | 1h | 2007-01-16 18:00 | 2007-01-16 19:00 | 22 | 2007-01-16 18:00 | 2007-01-16 19:00 | 1h | 26.25d | 0d | Matthew | 1h |
| 24 | 2.4.5 | Create MARC auth record parser | 4h | 2007-01-16 19:00 | 2007-01-18 19:00 | 23, 16 | 2007-01-16 19:00 | 2007-01-18 19:00 | 4h | 26.25d | 0d | Matthew | 4h |
| 25 | 2.4.6 | Create MARC name normalizer | 4h | 2007-01-18 19:00 | 2007-01-20 16:00 | 24, 16 | 2007-01-18 19:00 | 2007-01-20 16:00 | 4h | 26.25d |  | Matthew | 4h |

| ID | WBS | Task | Duration | Start | Finish | Predecessors | Baseline start | Baseline finish | Baseline duration | Total slack | Free slack | Resources | Work |
| --- | --- | --- | --- | --- | --- | --- | --- | --- | --- | --- | --- | --- | --- |
| 26 | 2.5 | **Authorize Name Matching** | 3d | 2007-01-13 15:00 | 2007-01-18 18:00 |  | 2007-01-09 16:00 | 2007-01-18 18:00 | 5.5d | 35.5d |  | Ben | 21h |
| 27 | 2.5.1 | Define rules for mapping MARC bib records to MARC auth records directly | 1h | 2007-01-13 15:00 | 2007-01-13 16:00 | 7 | 2007-01-11 18:00 | 2007-01-11 19:00 | 1h | 28.25d | 0.75d | Ben | 1h |
| 28 | 2.5.2 | Create the MatchStrategy for performing the direct mapping | 8h | 2007-01-14 15:00 | 2007-01-18 18:00 | 27, 16 | 2007-01-14 15:00 | 2007-01-18 18:00 | 8h | 27.5d |  | Ben | 8h |
| 29 | 2.6 | **Graphical User Interface - Core** | 6d | 2007-01-14 15:00 | 2007-01-25 18:00 |  | 2007-01-14 15:00 | 2007-01-25 18:00 | 6d | 29.5d | 0d | Rob | 48h |
| 30 | 2.6.1 | Import auth record | 2h | 2007-01-14 15:00 | 2007-01-14 17:00 | 16 | 2007-01-14 15:00 | 2007-01-14 17:00 | 2h | 21.5d | 0d | Rob | 2h |
| 31 | 2.6.2 | Import auth record folder | 2h | 2007-01-16 16:00 | 2007-01-16 18:00 | 30 | 2007-01-16 16:00 | 2007-01-16 18:00 | 2h | 21.5d | 0d | Rob | 2h |
| 32 | 2.6.3 | Import bib record | 2h | 2007-01-16 18:00 | 2007-01-16 20:00 | 31 | 2007-01-16 18:00 | 2007-01-16 20:00 | 2h | 21.5d | 0d | Rob | 2h |
| 33 | 2.6.4 | Import bib record folder | 2h | 2007-01-18 16:00 | 2007-01-18 18:00 | 32 | 2007-01-18 16:00 | 2007-01-18 18:00 | 2h | 21.5d | 0d | Rob | 2h |
| 34 | 2.6.5 | Match bib records in system to auth records in system | 2h | 2007-01-18 18:00 | 2007-01-18 20:00 | 33 | 2007-01-18 18:00 | 2007-01-18 20:00 | 2h | 21.5d | 0d | Rob | 2h |
| 35 | 2.6.6 | View all currently unconfirmed or unrejected matches | 14h | 2007-01-20 13:00 | 2007-01-25 18:00 | 34 | 2007-01-20 13:00 | 2007-01-25 18:00 | 14h | 21.5d |  | Rob | 14h |
| 36 | 2.7 | Systems Integeration | 6h | 2007-01-25 18:00 | 2007-01-27 17:00 | 29 |  |  |  | 21.5d | 0d | Matthew; Ben; Anthony; Dean; Rob | 30h |
| 37 | 2.8 | **Testing** | 0.5d | 2007-01-28 13:00 | 2007-01-28 15:00 | 29, 36 |  |  |  | 29.5d |  | Ben | 4h |
| 38 | 2.8.1 | Acceptance Tests | 2h | 2007-01-28 13:00 | 2007-01-28 15:00 |  |  |  |  | 21.5d |  | Ben | 2h |
| 39 | 3 | **Release 2** | 8d? | 2007-01-28 15:00 | 2007-02-11 15:00 | 4 |  |  |  | 29.5d |  | Anthony; Ben; Dean; Matthew; Rob | 298h |
| 40 | 3.1 | **Release 1 Issue Resolution** | 1d? | 2007-01-30 18:00 | 2007-02-01 18:00 | 64 |  |  |  | 29.5d | 0d |  | 4h |
| 41 | 3.1.1 | Import errors | 1d? | 2007-01-30 18:00 | 2007-02-01 18:00 |  |  |  |  | 21.5d |  | Matthew | 4h |
| 42 | 3.2 | **Import Dublin Core Records** | 2.5d | 2007-02-01 18:00 | 2007-02-04 17:00 | 40 |  |  |  | 29.5d | 0d | Matthew | 20h |
| 43 | 3.2.1 | Define Mapping of DC xml to domain objects | 4h | 2007-02-01 18:00 | 2007-02-03 15:00 |  |  |  |  | 21.5d | 0d | Matthew | 4h |
| 44 | 3.2.2 | Create DC bib record parser | 4h | 2007-02-03 15:00 | 2007-02-04 15:00 | 43 |  |  |  | 21.5d | 0d | Matthew | 4h |
| 45 | 3.2.3 | Create DC name normalizer | 2h | 2007-02-04 15:00 | 2007-02-04 17:00 | 44 |  |  |  | 21.5d |  | Matthew | 2h |
| 46 | 3.3 | **Auxiliary Name Matching** | 3d | 2007-01-30 16:00 | 2007-02-03 17:00 | 63 |  |  |  | 33d | 3.5d | Ben | 24h |
| 47 | 3.3.1 | Define rules for mapping bib records for auth records via alternative names | 2h | 2007-01-30 16:00 | 2007-01-30 18:00 |  |  |  |  | 25d | 0d | Ben | 2h |
| 48 | 3.3.2 | Create the MatchStrategy for performing the direct mapping | 10h | 2007-01-30 18:00 | 2007-02-03 17:00 | 47 |  |  |  | 25d |  | Ben | 10h |
| 49 | 3.4 | **Confirm/Reject posible match** | 2d | 2007-01-28 15:00 | 2007-02-01 18:00 |  |  |  |  | 32d | 0d | Rob | 16h |
| 50 | 3.4.1 | Cofirm a possible match and update database | 2h | 2007-01-28 15:00 | 2007-01-28 17:00 |  |  |  |  | 24d | 0d | Rob | 2h |
| 51 | 3.4.2 | Reject a possible match and update database | 2h | 2007-01-30 16:00 | 2007-01-30 18:00 | 50 |  |  |  | 24d | 0d | Rob | 2h |
| 52 | 3.4.3 | Record who confirmed or rejected a possible match | 1d | 2007-01-30 18:00 | 2007-02-01 18:00 | 51, 50 |  |  |  | 24d |  | Rob | 4h |

| ID | WBS | Task | Duration | Start | Finish | Predecessors | Total slack | Free slack | Constraint | Resources | Work |
| --- | --- | --- | --- | --- | --- | --- | --- | --- | --- | --- | --- |
| 53 | 3.5 | **Match duplicate incoming records** | 2.5d | 2007-02-06 16:00 | 2007-02-10 15:00 | 42 | 29.5d | 0d |  | Matthew | 20h |
| 54 | 3.5.1 | Create the hash of a xml record | 4h | 2007-02-06 16:00 | 2007-02-06 20:00 |  | 21.5d | 0d |  | Matthew | 4h |
| 55 | 3.5.2 | Apply hash search on import and import according to results | 6h | 2007-02-08 16:00 | 2007-02-10 15:00 | 54 | 21.5d |  |  | Matthew | 6h |
| 56 | 3.6 | **Filter/Sort all matches in the system** | 4.5d | 2007-01-28 15:00 | 2007-02-04 17:00 |  | 32d | 2.5d |  | Dean | 38h |
| 57 | 3.6.1 | Filter matches on a specific field | 6h | 2007-01-28 15:00 | 2007-01-30 20:00 |  | 26d | 0d |  | Dean | 6h |
| 58 | 3.6.2 | Sort matches on a specific field | 4h | 2007-02-01 16:00 | 2007-02-01 20:00 | 57 | 26d |  |  | Dean | 4h |
| 59 | 3.6.3 | Gui changes to make use of filter/sort | 10h | 2007-02-01 18:00 | 2007-02-04 17:00 | 49 | 24d |  |  | Rob | 10h |
| 60 | 3.7 | **Documentation** | 1.5d | 2007-01-28 15:00 | 2007-01-30 20:00 |  | 29.5d | 5.5d |  |  | 12h |
| 61 | 3.7.1 | Architecture Design Document | 4h | 2007-01-28 15:00 | 2007-01-30 18:00 |  | 27d | 0d |  | Anthony | 4h |
| 62 | 3.7.2 | Metrics | 2h | 2007-01-30 18:00 | 2007-01-30 20:00 | 61 | 27d |  |  | Anthony | 2h |
| 63 | 3.7.3 | Acceptence Test Generation | 2h | 2007-01-28 15:00 | 2007-01-28 17:00 |  | 25d | 0d |  | Ben | 2h |
| 64 | 3.7.4 | Project Schedule | 4h | 2007-01-28 15:00 | 2007-01-30 18:00 |  | 21.5d | 0d |  | Matthew | 4h |
| 65 | 3.8 | **Testing** | 1d | 2007-02-10 15:00 | 2007-02-11 15:00 | 60, 56, 53, 49, 46, 42 | 29.5d | 15.5d |  |  | 4h |
| 66 | 3.8.1 | Acceptance Tests | 4h | 2007-02-10 15:00 | 2007-02-11 15:00 |  | 21.5d |  |  | Ben | 4h |
| 67 | 4 | Finals Break | 1d? | 2007-03-11 13:00 | 2007-03-11 17:00 | 65 | 14d | 0d | finish no earlier than 2007-03-11 17:00 |  |  |
| 68 | 5 | **Release 3** | 12d | 2007-03-13 16:00 | 2007-04-01 17:00 | 67 | 14d |  |  | Anthony; Ben; Dean; Matthew; Rob | 501h |
| 69 | 5.1 | **Update Stored Information** | 5.5d | 2007-03-13 16:00 | 2007-03-22 18:00 |  | 14d | 0d |  | Anthony | 76h |
| 70 | 5.1.1 | Discuss what information needs to be stored | 8h | 2007-03-13 16:00 | 2007-03-15 20:00 |  | 6d | 0d |  | Matthew; Anthony; Ben; Dean; Rob | 40h |
| 71 | 5.1.2 | Implement changes in document model | 8h | 2007-03-17 13:00 | 2007-03-18 17:00 | 70 | 6d | 0d |  | Dean | 8h |
| 72 | 5.1.3 | Implement changes in importer | 6h | 2007-03-20 16:00 | 2007-03-22 18:00 | 71 | 6d |  |  | Matthew | 6h |
| 73 | 5.2 | **String Transformation** | 6.5d | 2007-03-22 18:00 | 2007-04-01 17:00 | 69 | 14d |  |  | Anthony | 52h |
| 74 | 5.2.1 | Research desired string transformations | 10h | 2007-03-22 18:00 | 2007-03-25 17:00 |  | 6d | 0d |  | Anthony | 10h |
| 75 | 5.2.2 | Create string transformation classes | 16h | 2007-03-27 16:00 | 2007-04-01 17:00 | 74 | 6d |  |  | Anthony | 16h |
| 76 | 5.3 | **Match updated incoming records** | 4d | 2007-03-13 16:00 | 2007-03-18 17:00 |  | 18.5d | 0d |  | Matthew | 32h |
| 77 | 5.3.1 | Identify a incoming record as being a update | 8h | 2007-03-13 16:00 | 2007-03-15 20:00 |  | 10.5d | 0d |  | Matthew | 8h |
| 78 | 5.3.2 | Update the existing record with new information | 8h | 2007-03-17 13:00 | 2007-03-18 17:00 | 77 | 10.5d |  |  | Matthew | 8h |

| ID | WBS | Task | Duration | Start | Finish | Predecessors | Total slack | Free slack | Constraint | Resources | Work |
| --- | --- | --- | --- | --- | --- | --- | --- | --- | --- | --- | --- |
| 79 | 5.4 | **Creation of auth records based on unmatched bib records** | 3.25d | 2007-03-13 16:00 | 2007-03-18 14:00 |  | 21.75d | 0.75d |  | Ben | 26h |
| 80 | 5.4.1 | Identify a unmatchable record | 1h | 2007-03-13 16:00 | 2007-03-13 17:00 |  | 13.75d | 0d |  | Ben | 1h |
| 81 | 5.4.2 | Pull relevent information from a bib record to create the auth record | 4h | 2007-03-13 17:00 | 2007-03-15 17:00 | 80 | 13.75d | 0d |  | Ben | 4h |
| 82 | 5.4.3 | Create the auth record | 2h | 2007-03-15 17:00 | 2007-03-15 19:00 | 81 | 13.75d | 0d |  | Ben | 2h |
| 83 | 5.4.4 | Match the bib record to the auth record | 2h | 2007-03-15 19:00 | 2007-03-17 14:00 | 82 | 13.75d | 0d |  | Ben | 2h |
| 84 | 5.4.5 | Confirm or reject a generated auth record | 4h | 2007-03-17 14:00 | 2007-03-18 14:00 | 83 | 13.75d | 0d |  | Rob | 4h |
| 85 | 5.5 | **Configuration File** | 3d | 2007-03-13 16:00 | 2007-03-17 17:00 |  | 22d | 1d |  | Dean | 24h |
| 86 | 5.5.1 | Create format for configuration file | 2h | 2007-03-13 16:00 | 2007-03-13 18:00 |  | 14d | 0d |  | Dean | 2h |
| 87 | 5.5.2 | Implement access to configuration file | 4h | 2007-03-13 18:00 | 2007-03-15 18:00 | 86 | 14d | 0d |  | Dean | 4h |
| 88 | 5.5.3 | Update matching to make use of configuration file | 6h | 2007-03-15 18:00 | 2007-03-17 17:00 | 87 | 14d |  |  | Ben | 6h |
| 89 | 5.6 | **Logging import and match process** | 1d | 2007-03-20 16:00 | 2007-03-20 20:00 | 76, 79, 85 | 21d |  |  | Rob | 16h |
| 90 | 5.6.1 | Logging import | 4h | 2007-03-20 16:00 | 2007-03-20 20:00 |  | 13d |  |  | Matthew | 4h |
| 91 | 5.6.2 | Logging match process | 4h | 2007-03-20 16:00 | 2007-03-20 20:00 |  | 13d |  |  | Rob | 4h |
| 92 | 5.6.3 | Logging confirms / rejections | 4h | 2007-03-20 16:00 | 2007-03-20 20:00 |  | 13d |  |  | Rob | 4h |
| 93 | 5.7 | **Gui updates** | 4.25d | 2007-03-18 14:00 | 2007-03-25 15:00 |  | 18.5d |  |  | Matthew | 35h |
| 94 | 5.7.1 | Show xml for for matches for Auth records | 4h | 2007-03-20 16:00 | 2007-03-20 20:00 | 76 | 10.5d | 0d |  | Matthew | 4h |
| 95 | 5.7.2 | Show xml for matches for Bib records | 4h | 2007-03-22 16:00 | 2007-03-22 20:00 | 94 | 10.5d | 0d |  | Matthew | 4h |
| 96 | 5.7.3 | Estimated / Actual time for processes | 6h | 2007-03-24 13:00 | 2007-03-25 15:00 | 95 | 10.5d |  |  | Matthew | 6h |
| 97 | 5.7.4 | Selecting mutiple files for import box | 4h | 2007-03-18 14:00 | 2007-03-20 17:00 | 84 | 13.75d |  |  | Ben | 4h |
| 98 | 5.8 | **Release 4 Planning** | 2d | 2007-03-20 16:00 | 2007-03-22 20:00 |  | 20d |  |  |  |  |
| 99 | 5.8.1 | Define features | 4h | 2007-03-20 16:00 | 2007-03-20 20:00 |  | 6d | 0d | start no earlier than 2007-03-20 08:00 |  |  |
| 100 | 5.8.2 | Break up into sub tasks | 2h | 2007-03-22 16:00 | 2007-03-22 18:00 | 99 | 6d | 0d |  |  |  |
| 101 | 5.8.3 | Time estimate sub tasks | 2h | 2007-03-22 18:00 | 2007-03-22 20:00 | 100 | 6d |  |  |  |  |
| 102 | 6 | **Release 4** | 12d? | 2007-04-03 16:00 | 2007-04-22 17:00 |  | 0d |  |  |  | 52h |
| 103 | 6.1 | **Software Engineering Documents** | 4d | 2007-04-17 16:00 | 2007-04-22 17:00 |  | 0d |  |  |  | 16h |
| 104 | 6.1.1 | Poster | 8h | 2007-04-17 16:00 | 2007-04-19 20:00 |  | 0d |  | start no earlier than 2007-04-17 08:00 | Rob | 8h |
| 105 | 6.1.2 | Presentation | 4h | 2007-04-21 13:00 | 2007-04-21 17:00 | 104 | 0d |  |  | Anthony | 4h |
| 106 | 6.1.3 | Question Sheet | 4h | 2007-04-22 13:00 | 2007-04-22 17:00 | 105 | 0d |  |  | Ben | 4h |

| ID | WBS | Task | Duration | Start | Finish | Predecessors | Total slack | Free slack | Constraint | Resources | Work |
| --- | --- | --- | --- | --- | --- | --- | --- | --- | --- | --- | --- |
| 107 | 6.2 | **Development** | 6d | 2007-04-03 16:00 | 2007-04-12 20:00 |  | 5d | 0d |  |  | 20h |
| 108 | 6.2.1 | **Common Name Detection** | 6d | 2007-04-03 16:00 | 2007-04-12 20:00 |  | 5d |  |  |  | 20h |
| 109 | 6.2.1.1 | Update Mysql | 6h | 2007-04-03 16:00 | 2007-04-05 18:00 |  | 2.5d |  | start no earlier than 2007-04-03 08:00 | Anthony | 6h |
| 110 | 6.2.1.2 | Update DAO | 6h | 2007-04-03 16:00 | 2007-04-05 18:00 |  | 2.5d |  | start no earlier than 2007-04-03 08:00 | Dean | 6h |
| 111 | 6.2.1.3 | Update Java Code | 8h | 2007-04-10 16:00 | 2007-04-12 20:00 |  | 5d |  | start no earlier than 2007-04-10 08:00 | Anthony | 8h |
| 112 | 6.3 | **Optimize Performance** | 2d? | 2007-04-03 16:00 | 2007-04-05 20:00 |  | 9d | 4d |  |  | 8h |
| 113 | 6.3.1 | Optimze Mysql | 8h | 2007-04-03 16:00 | 2007-04-05 20:00 |  | 2d |  | start no earlier than 2007-04-03 08:00 | Anthony | 8h |
| 114 | 6.3.2 | Optimize Matching | 1d? | 2007-04-03 16:00 | 2007-04-03 20:00 |  | 3d |  | start no earlier than 2007-04-03 08:00 |  |  |
| 115 | 6.4 | **Testing** | 7d | 2007-04-03 16:00 | 2007-04-14 17:00 |  | 5d |  |  |  | 8h |
| 116 | 6.4.1 | Acceptance Testing | 1d | 2007-04-14 13:00 | 2007-04-14 17:00 | 107, 112 | 5d |  | start no earlier than 2007-04-03 08:00 | Ben | 4h |
| 117 | 6.4.2 | Usabilty Testing | 1d | 2007-04-03 16:00 | 2007-04-03 20:00 |  | 3d |  | start no earlier than 2007-04-03 08:00 | Rob | 4h |
