# Name Access Control Module Project Schedule

Schedule from MS Project, 2007-01-09 to 2007-03-17, 4 hours a day.
Venaca

## Calendars

- Standard: Mon off; Tue 16:00-20:00; Wed off; Thu 16:00-20:00; Fri off; Sat-Sun 13:00-17:00.

## Resources

| Resource |
| --- |
| Matthew |
| Ben |
| Anthony |
| Dean |
| Rob |

## Schedule

| ID | WBS | Task | Duration | Start | Finish | Predecessors | Baseline start | Baseline finish | Baseline duration | Total slack | Free slack | Resources | Work |
| --- | --- | --- | --- | --- | --- | --- | --- | --- | --- | --- | --- | --- | --- |
| 1 | 1 | **Pre-Release** | 4d | 2007-01-09 16:00 | 2007-01-14 17:00 |  |  |  |  | 0d |  | Ben; Matthew; Rob | 96h |
| 2 | 1.1 | SRS Document | 1w | 2007-01-09 16:00 | 2007-01-14 17:00 |  |  |  |  | 0d |  | Ben; Matthew; Rob | 48h |
| 3 | 2 | **Release 1** | 9.5d | 2007-01-16 16:00 | 2007-02-01 18:00 | 1 | 2007-01-09 16:00 | 2007-01-25 18:00 | 9.5d | 0d |  | Anthony; Ben; Dean; Matthew; Rob | 422h |
| 4 | 2.1 | **Java Refreasher** | 1.5d | 2007-01-16 16:00 | 2007-01-18 18:00 |  |  |  |  | 4.5d |  |  | 8h |
| 5 | 2.1.1 | Java refresher for Matthew | 2h | 2007-01-16 16:00 | 2007-01-16 18:00 |  | 2007-01-09 16:00 | 2007-01-09 18:00 | 2h | 4.5d | 0d | Matthew | 2h |
| 6 | 2.1.2 | Java refresher for Ben | 6h | 2007-01-16 16:00 | 2007-01-18 18:00 |  | 2007-01-09 16:00 | 2007-01-11 18:00 | 6h | 5.75d | 0d | Ben | 6h |
| 7 | 2.2 | **Database** | 5.5d | 2007-01-16 16:00 | 2007-01-25 18:00 |  | 2007-01-09 16:00 | 2007-01-18 18:00 | 5.5d | 0d |  | Anthony | 44h |
| 8 | 2.2.1 | Setup server machine | 3h | 2007-01-16 16:00 | 2007-01-16 19:00 |  | 2007-01-09 16:00 | 2007-01-09 19:00 | 3h | 0d |  | Anthony | 3h |
| 9 | 2.2.2 | Install mySql on server machine | 3h | 2007-01-16 19:00 | 2007-01-18 18:00 | 8 | 2007-01-09 19:00 | 2007-01-11 18:00 | 3h | 0d |  | Anthony | 3h |
| 10 | 2.2.3 | Define the database schema | 4h | 2007-01-18 18:00 | 2007-01-20 15:00 | 9 | 2007-01-11 18:00 | 2007-01-13 15:00 | 4h | 0d |  | Anthony | 4h |
| 11 | 2.2.4 | Create the database creation script | 12h | 2007-01-20 15:00 | 2007-01-25 18:00 | 10 | 2007-01-13 15:00 | 2007-01-18 18:00 | 12h | 4d |  | Anthony | 12h |
| 12 | 2.3 | **Data Access Object** | 8.5d | 2007-01-16 16:00 | 2007-01-30 18:00 |  | 2007-01-09 16:00 | 2007-01-23 18:00 | 8.5d | 1d |  | Dean | 64h |
| 13 | 2.3.1 | Hibernate learning curve | 3h | 2007-01-16 16:00 | 2007-01-16 19:00 |  | 2007-01-09 16:00 | 2007-01-09 19:00 | 3h | 1d | 0d | Dean | 3h |
| 14 | 2.3.2 | Install Hibernate | 3h | 2007-01-16 19:00 | 2007-01-18 18:00 | 13 | 2007-01-09 19:00 | 2007-01-11 18:00 | 3h | 1d |  | Dean | 3h |
| 15 | 2.3.3 | Setup domain model | 4h | 2007-01-20 15:00 | 2007-01-21 15:00 | 14, 10 | 2007-01-13 15:00 | 2007-01-14 15:00 | 4h | 0d |  | Dean | 4h |
| 16 | 2.3.4 | Define xml mappings for Hibernate | 12h | 2007-01-21 15:00 | 2007-01-27 15:00 | 15 | 2007-01-14 15:00 | 2007-01-20 15:00 | 12h | 1d | 0d | Dean | 12h |
| 17 | 2.3.5 | Define interface to database through Hibernate | 8h | 2007-01-27 15:00 | 2007-01-30 18:00 | 16 | 2007-01-20 15:00 | 2007-01-23 18:00 | 8h | 1d |  | Dean | 8h |
| 18 | 2.4 | **Import MARC Records** | 6.25d | 2007-01-16 18:00 | 2007-01-27 16:00 |  | 2007-01-09 16:00 | 2007-01-20 16:00 | 6.75d | 2.75d |  | Matthew | 43h |
| 19 | 2.4.1 | XML Jave learning curve | 4h | 2007-01-16 18:00 | 2007-01-18 18:00 | 5 | 2007-01-09 18:00 | 2007-01-11 18:00 | 4h | 4.5d | 0d | Matthew | 4h |
| 20 | 2.4.2 | Define mapping of MARC bib xml to domain objects | 1h | 2007-01-18 18:00 | 2007-01-18 19:00 | 19 | 2007-01-11 18:00 | 2007-01-11 19:00 | 1h | 4.5d | 1.75d | Matthew | 1h |
| 21 | 2.4.3 | Create MARC bib record parser | 4h | 2007-01-21 15:00 | 2007-01-23 18:00 | 20, 15 | 2007-01-14 15:00 | 2007-01-16 18:00 | 4h | 2.75d | 0d | Matthew | 4h |
| 22 | 2.4.4 | Define mapping of MARC auth xml to domain objects | 1h | 2007-01-23 18:00 | 2007-01-23 19:00 | 21 | 2007-01-16 18:00 | 2007-01-16 19:00 | 1h | 2.75d | 0d | Matthew | 1h |
| 23 | 2.4.5 | Create MARC auth record parser | 4h | 2007-01-23 19:00 | 2007-01-25 19:00 | 22, 15 | 2007-01-16 19:00 | 2007-01-18 19:00 | 4h | 2.75d | 0d | Matthew | 4h |
| 24 | 2.4.6 | Create MARC name normalizer | 4h | 2007-01-25 19:00 | 2007-01-27 16:00 | 23, 15 | 2007-01-18 19:00 | 2007-01-20 16:00 | 4h | 2.75d |  | Matthew | 4h |

| ID | WBS | Task | Duration | Start | Finish | Predecessors | Baseline start | Baseline finish | Baseline duration | Total slack | Free slack | Resources | Work |
| --- | --- | --- | --- | --- | --- | --- | --- | --- | --- | --- | --- | --- | --- |
| 25 | 2.5 | **Authorize Name Matching** | 4d | 2007-01-18 18:00 | 2007-01-25 18:00 |  | 2007-01-09 16:00 | 2007-01-18 18:00 | 5.5d | 4d |  | Ben | 25h |
| 26 | 2.5.1 | Define rules for mapping MARC bib records to MARC auth records directly | 1h | 2007-01-18 18:00 | 2007-01-18 19:00 | 6 | 2007-01-11 18:00 | 2007-01-11 19:00 | 1h | 5.75d | 1.75d | Ben | 1h |
| 27 | 2.5.2 | Create the MatchStrategy for performing the mapping | 8h | 2007-01-21 15:00 | 2007-01-25 18:00 | 26, 15 | 2007-01-14 15:00 | 2007-01-18 18:00 | 8h | 4d |  | Ben | 8h |
| 28 | 2.6 | **Graphical User Interface** | 6d | 2007-01-21 15:00 | 2007-02-01 18:00 |  | 2007-01-14 15:00 | 2007-01-25 18:00 | 6d | 0d |  | Rob | 48h |
| 29 | 2.6.1 | Import auth record | 2h | 2007-01-21 15:00 | 2007-01-21 17:00 | 15 | 2007-01-14 15:00 | 2007-01-14 17:00 | 2h | 0d |  | Rob | 2h |
| 30 | 2.6.2 | Import auth record folder | 2h | 2007-01-23 16:00 | 2007-01-23 18:00 | 29 | 2007-01-16 16:00 | 2007-01-16 18:00 | 2h | 0d |  | Rob | 2h |
| 31 | 2.6.3 | Import bib record | 2h | 2007-01-23 18:00 | 2007-01-23 20:00 | 30 | 2007-01-16 18:00 | 2007-01-16 20:00 | 2h | 0d |  | Rob | 2h |
| 32 | 2.6.4 | Import bib record folder | 2h | 2007-01-25 16:00 | 2007-01-25 18:00 | 31 | 2007-01-18 16:00 | 2007-01-18 18:00 | 2h | 0d |  | Rob | 2h |
| 33 | 2.6.5 | Match bib records in system to auth records in system | 2h | 2007-01-25 18:00 | 2007-01-25 20:00 | 32 | 2007-01-18 18:00 | 2007-01-18 20:00 | 2h | 0d |  | Rob | 2h |
| 34 | 2.6.6 | View resulting report | 14h | 2007-01-27 13:00 | 2007-02-01 18:00 | 33 | 2007-01-20 13:00 | 2007-01-25 18:00 | 14h | 0d |  | Rob | 14h |
| 35 | 3 | **Release 2** | 1d? | 2007-02-01 18:00 | 2007-02-03 15:00 | 3 |  |  |  | 0d |  | Anthony; Ben; Dean; Matthew; Rob | 40h |
| 36 | 3.1 | **Import Dublin Core Records** | 1d? | 2007-02-01 18:00 | 2007-02-03 15:00 |  |  |  |  | 0d |  | Matthew | 16h |
| 37 | 3.1.1 | Define Mapping of DC xml to domain objects | 1d? | 2007-02-01 18:00 | 2007-02-03 15:00 |  |  |  |  | 0d |  | Matthew | 4h |
| 38 | 3.1.2 | Create DC bib record parser | 1d? | 2007-02-01 18:00 | 2007-02-03 15:00 |  |  |  |  | 0d |  | Matthew | 4h |
| 39 | 3.1.3 | Create DC name normalizer | 1d? | 2007-02-01 18:00 | 2007-02-03 15:00 |  |  |  |  | 0d |  | Matthew | 4h |
| 40 | 3.2 | Auxiliary Name Matching | 1d? | 2007-02-01 18:00 | 2007-02-03 15:00 |  |  |  |  | 24d |  | Ben | 4h |
| 41 | 4 | Release 3 | 3w | 2007-02-03 15:00 | 2007-02-24 15:00 | 36 |  |  |  | 0d |  | Anthony; Ben; Dean; Matthew; Rob | 240h |
| 42 | 5 | Release 4 | 3w | 2007-02-24 15:00 | 2007-03-17 15:00 | 41 |  |  |  | 0d |  | Anthony; Ben; Dean; Matthew; Rob | 240h |
